# Pars

Schedule from Primavera P6, 2023-03-11 to 2023-06-13, data date 2022-11-24, costs in USD, A marks actual dates.
ï»؟

## Calendars

- Persian: Mon-Sun 08:00-16:00. Exceptions (off unless hours are given): 2023-03-21 to 2023-03-24, 2023-04-02.

## Resources

| Resource | Group | Unit | Rate | Notes |
| --- | --- | --- | --- | --- |
| بيل مکانيکي | equipment |  | 312500 | ï»؟ |
| بتن مگر | material | m3 | 900000 | ï»؟ |
| بتن ريز | labor |  | 60000 | ï»؟ |
| آرماتوربند | labor |  | 50000 | ï»؟ |
| کارگر آرماتوربندي | labor |  | 25000 | ï»؟ |
| ميلگرد | material | kg | 1200000 | ï»؟ |
| قالب بند | labor |  | 50000 | ï»؟ |
| کارگر قالب بندي | labor |  | 25000 | ï»؟ |
| قالب | equipment |  | 5000 | ï»؟ |
| بتن 400 | material | m3 | 1400000 | ï»؟ |
| پمپ زميني | equipment |  | 150000 | ï»؟ |
| بتن 350 | material | m3 | 1200000 | ï»؟ |
| پمپ هوايي | equipment |  | 312500 | ï»؟ |
| ميلگرد حرارتي | material | kg | 15000 | ï»؟ |
| فوم سقفي | material | Unit |  | ï»؟ |
| تيرچه بتني | material | ml | 110000 | ï»؟ |

## Schedule

| ID | WBS | Activity | Type | Duration | Start | Finish | Predecessors | Total float | Resources | Cost | wf |
| --- | --- | --- | --- | --- | --- | --- | --- | --- | --- | --- | --- |
|  | 1 | **خاکبرداري** |  |  | 2023-03-11 | 2023-03-17 |  |  |  |  |  |
| A1000 |  | شروع | milestone | 0d | 2023-03-11 | 2023-03-11 |  | 0d |  |  |  |
| A1010 |  | خاکبرداري |  | 7d | 2023-03-11 | 2023-03-17 | A1000 | 0d | بيل مکانيکي [56 h] | 17,500,000 |  |
|  | 2 | **فونداسيون** |  |  | 2023-03-18 | 2023-03-31 |  |  |  |  |  |
| A1020 |  | بتن مگر |  | 1d | 2023-03-18 | 2023-03-18 | A1010 | 0d | بتن مگر [20 m3]; بتن ريز [16 h] | 18,960,000 |  |
| A1030 |  | آرماتوربندي |  | 7d | 2023-03-19 | 2023-03-29 | A1020 | 0d | آرماتوربند [280 h]; کارگر آرماتوربندي [224 h]; ميلگرد [4200 kg] | 5,059,600,000 | 13.6186403861755 |
| A1040 |  | قالب بندي |  | 7d | 2023-03-25 | 2023-03-31 | A1030 FS-5d | 0d | قالب بند [280 h]; کارگر قالب بندي [224 h]; قالب [1280 h] | 26,000,000 | 0.0699827357974075 |
| A1050 |  | بتن ريزي |  | 1d | 2023-03-30 | 2023-03-30 | A1040 FS-2d | 0d | بتن ريز [32 h]; بتن 400 [70 m3]; پمپ زميني [8 h] | 101,200,000 | 0.272394340872986 |
|  | 3 | **اسکلت** |  |  | 2023-03-31 | 2023-06-13 |  |  |  |  |  |
|  | 1 | **طبقه همکف** |  |  | 2023-03-31 | 2023-04-19 |  |  |  |  |  |
|  | 1 | **ستون** |  |  | 2023-03-31 | 2023-04-08 |  |  |  |  |  |
| A1060 |  | آرماتوربندي |  | 5d | 2023-03-31 | 2023-04-05 | A1050 | 0d | آرماتوربند [160 h]; ميلگرد [3500 kg]; کارگر آرماتوربندي [120 h] | 4,211,000,000 | 11.3345115554955 |
| A1070 |  | قالب بندي |  | 5d | 2023-04-03 | 2023-04-07 | A1060 FS-3d | 0d | قالب بند [120 h]; کارگر قالب بندي [80 h]; قالب [480 h] | 10,400,000 | 0.027993094318963 |
| A1080 |  | بتن ريزي |  | 1d | 2023-04-08 | 2023-04-08 | A1070 | 0d | بتن 350 [30 m3]; بتن ريز [8 h]; پمپ هوايي [8 h] | 38,980,000 | 0.104920270822421 |
|  | 2 | **سقف** |  |  | 2023-04-09 | 2023-04-19 |  |  |  |  |  |
| A1090 |  | قالب بندي |  | 7d | 2023-04-09 | 2023-04-15 | A1080 | 0d | قالب بند [336 h]; کارگر قالب بندي [280 h]; قالب [960 h] | 28,600,000 | 0.0769810093771483 |
| A1100 |  | اجراي تير و سقف |  | 7d | 2023-04-12 | 2023-04-18 | A1090 FS-4d | 0d | آرماتوربند [336 h]; کارگر آرماتوربندي [280 h]; ميلگرد [3000 kg]; ميلگرد حرارتي [500 kg]; فوم سقفي [50 Unit]; تيرچه بتني [150 ml] | 3,647,800,000 | 9.81857783237627 |
| A1110 |  | بتن ريزي |  | 1d | 2023-04-19 | 2023-04-19 | A1100 | 0d | بتن ريز [32 h]; بتن 350 [35 m3]; پمپ زميني [8 h] | 45,120,000 | 0.121446963045347 |
|  | 3 | **طبقه اول** |  |  | 2023-04-20 | 2023-05-07 |  |  |  |  |  |
|  | 1 | **ستون** |  |  | 2023-04-20 | 2023-04-27 |  |  |  |  |  |
| A1120 |  | آرماتوربندي |  | 5d | 2023-04-20 | 2023-04-24 | A1110 | 0d | آرماتوربند [160 h]; کارگر آرماتوربندي [120 h]; ميلگرد [3500 kg] | 4,211,000,000 | 11.3345115554955 |
| A1130 |  | قالبنبدي |  | 5d | 2023-04-22 | 2023-04-26 | A1120 FS-3d | 0d | قالب بند [120 h]; کارگر قالب بندي [80 h]; قالب [480 h] | 10,400,000 | 0.027993094318963 |
| A1140 |  | بتن ريزي |  | 1d | 2023-04-27 | 2023-04-27 | A1130 | 0d | بتن ريز [8 h]; بتن 350 [30 m3]; پمپ هوايي [8 h] | 38,980,000 | 0.104920270822421 |
|  | 2 | **سقف** |  |  | 2023-04-28 | 2023-05-07 |  |  |  |  |  |
| A1150 |  | قالب بندي |  | 7d | 2023-04-28 | 2023-05-04 | A1140 | 0d | قالب بند [336 h]; کارگر قالب بندي [280 h]; قالب [960 h] | 28,600,000 | 0.0769810093771483 |
| A1160 |  | اجراي تير و سقف |  | 7d | 2023-05-01 | 2023-05-07 | A1150 FS-4d | 0d | آرماتوربند [336 h]; کارگر آرماتوربندي [280 h]; ميلگرد [3000 kg]; ميلگرد حرارتي [500 kg]; فوم سقفي [50 Unit]; تيرچه بتني [150 ml] | 3,647,800,000 | 9.81857783237627 |
| A1170 |  | بتن ريزي |  | 1d | 2023-05-06 | 2023-05-06 | A1160 FS-2d | 0d | بتن ريز [32 h]; بتن 350 [35 m3]; پمپ هوايي [8 h] | 46,420,000 | 0.124946099835218 |

Notes:
- A1050: Expenses: نهار بتن ريزي 80000

| ID | WBS | Activity | Type | Duration | Start | Finish | Predecessors | Remaining | Total float | Resources | Cost | Actual cost | wf |
| --- | --- | --- | --- | --- | --- | --- | --- | --- | --- | --- | --- | --- | --- |
|  | 2 | **طبقه دوم** |  |  | 2023-05-07 | 2023-05-25 |  |  |  |  |  |  |  |
|  | 1 | **ستون** |  |  | 2023-05-07 | 2023-05-14 |  |  |  |  |  |  |  |
| A1180 |  | آرماتوربندي |  | 5d | 2023-05-07 | 2023-05-11 | A1170 |  | 0d | آرماتوربند [160 h]; کارگر آرماتوربندي [120 h]; ميلگرد [3500 kg] | 4,211,000,000 |  | 11.3345115554955 |
| A1190 |  | قاالب بندي |  | 5d | 2023-05-09 | 2023-05-13 | A1180 FS-3d |  | 0d | قالب بند [120 h]; کارگر قالب بندي [80 h]; قالب [480 h] | 10,400,000 |  | 0.027993094318963 |
| A1200 |  | بتن ريزي |  | 1d | 2023-05-14 | 2023-05-14 | A1190 |  | 0d | بتن ريز [8 h]; بتن 350 [30 m3]; پمپ هوايي [8 h] | 38,980,000 |  | 0.104920270822421 |
|  | 2 | **سقف** |  |  | 2023-05-15 | 2023-05-25 |  |  |  |  |  |  |  |
| A1210 |  | قالب بندي |  | 7d | 2023-05-15 | 2023-05-21 | A1200 |  | 0d | قالب بند [336 h]; کارگر قالب بندي [280 h]; قالب [960 h] | 28,600,000 |  | 0.0769810093771483 |
| A1220 |  | اجراي تير و سقف |  | 7d | 2023-05-18 | 2023-05-24 | A1210 FS-4d |  | 0d | آرماتوربند [336 h]; کارگر آرماتوربندي [280 h]; ميلگرد [3000 kg]; ميلگرد حرارتي [500 kg]; فوم سقفي [50 Unit]; تيرچه بتني [150 ml] | 3,647,800,000 |  | 9.81857783237627 |
| A1230 |  | بتن ريزي |  | 1d | 2023-05-25 A | 2023-05-25 | A1220 | 1d | 0d | بتن ريز [8 h]; بتن 350 [35 m3]; پمپ هوايي [8 h] | 44,980,000 | 1,920,000 | 0.121070132929515 |
|  | 4 | **طبقه سوم** |  |  | 2023-05-26 | 2023-06-13 |  |  |  |  |  |  |  |
|  | 1 | **ستون** |  |  | 2023-05-26 | 2023-06-02 |  |  |  |  |  |  |  |
| A1240 |  | آرماتوربندي |  | 5d | 2023-05-26 | 2023-05-30 | A1230 |  | 0d | آرماتوربند [160 h]; کارگر آرماتوربندي [120 h]; ميلگرد [3500 kg] | 4,211,000,000 |  | 11.3345115554955 |
| A1250 |  | قالب بندي |  | 5d | 2023-05-28 | 2023-06-01 | A1240 FS-3d |  | 0d | قالب بند [120 h]; کارگر قالب بندي [80 h]; قالب [480 h] | 10,400,000 |  | 0.027993094318963 |
| A1260 |  | بتن ريزي |  | 1d | 2023-06-02 | 2023-06-02 | A1250 |  | 0d | بتن ريز [8 h]; بتن 350 [30 m3]; پمپ هوايي [8 h] | 38,980,000 |  | 0.104920270822421 |
|  | 2 | **سقف** |  |  | 2023-06-03 | 2023-06-13 |  |  |  |  |  |  |  |
| A1270 |  | قالب بندي |  | 7d | 2023-06-03 | 2023-06-09 | A1260 |  | 0d | قالب بند [336 h]; کارگر قالب بندي [280 h]; قالب [960 h] | 28,600,000 |  | 0.0769810093771483 |
| A1280 |  | اجراي تير و سقف |  | 7d | 2023-06-06 | 2023-06-12 | A1270 FS-4d |  | 0d | آرماتوربند [336 h]; کارگر آرماتوربندي [280 h]; ميلگرد [3000 kg]; ميلگرد حرارتي [500 kg]; فوم سقفي [50 Unit]; تيرچه بتني [150 ml] | 3,647,800,000 |  | 9.81857783237627 |
| A1290 |  | بتن ريزي |  | 1d | 2023-06-13 | 2023-06-13 | A1280 |  | 0d | بتن ريز [32 h]; بتن 350 [35 m3]; پمپ زميني [8 h] | 45,120,000 |  | 0.121446963045347 |
| A1300 |  | پايان | milestone | 0d | 2023-06-13 | 2023-06-13 | A1290 |  | 0d |  |  |  | 0 |
